Schedule from MS Project, 2012-09-25 to 2013-06-25.

## Calendars

- Standard: Mon-Fri 08:00-12:00, 13:00-17:00; Sat-Sun off.

## Schedule

| ID | WBS | Task | Duration | Start | Finish | Total slack | Constraint |
| --- | --- | --- | --- | --- | --- | --- | --- |
| 2 | 1 | Control Scheme Development for 1st Deployment | 23d? | 2012-09-25 | 2012-10-25 | 111d | start no earlier than 2012-09-25 |
| 3 | 2 | 1st Test Deployment Preparations | 31d? | 2012-09-25 | 2012-11-06 | 103d | start no earlier than 2012-09-25 |
| 4 | 3 | 1st Test Deployment | 23d? | 2012-11-07 | 2012-12-07 | 80d | finish no earlier than 2012-12-07 |
| 5 | 4 | 1st Test Data Analysis | 24d? | 2012-12-10 | 2013-01-10 | 56d | finish no earlier than 2013-01-10 |
| 6 | 5 | Control Scheme Development for 2nd Deployment | 41d? | 2013-01-14 | 2013-03-11 | 14d | finish no earlier than 2013-03-11 |
| 7 | 6 | 2nd Test Deployment Preparations | 41d? | 2013-02-01 | 2013-03-29 | 62d | finish no earlier than 2013-03-29 |
| 8 | 7 | 2nd Test Deployment | 22d? | 2013-04-01 | 2013-04-30 | 40d | finish no earlier than 2013-04-30 |
| 9 | 8 | 2nd Test Data Analysis | 23d? | 2013-05-01 | 2013-05-31 | 17d | finish no earlier than 2013-05-31 |
| 10 | 9 | Final Project Report | 126d? | 2013-01-01 | 2013-06-25 | 0d | finish no earlier than 2013-06-25 |
| 11 | 10 | Numerical Code Transistion | 196d? | 2012-09-25 | 2013-06-25 | 0d | finish no earlier than 2013-06-25 |
